# ESP Deployments

Schedule from MS Project, 2006-10-02 to 2008-03-28.
MBARI

## Calendars

- Standard: Mon-Fri 08:00-12:00, 13:00-17:00; Sat-Sun off.

## Resources

| Resource |
| --- |
| 29 |
| Science |
| Kevin |
| ME_Tech |
| EE_Tech |
| SE |
| EE |
| ME |
| Team |

## Schedule

| ID | WBS | Task | Type | Duration | Start | Finish | Predecessors | Total slack | Free slack | Constraint |
| --- | --- | --- | --- | --- | --- | --- | --- | --- | --- | --- |
| 1 | 1 | **Deployments** |  | 213d | 2006-12-04 | 2007-09-27 |  | 0d |  |  |
| 2 | 1.1 | DWSM Engineering D1 | milestone | 0d | 2006-12-04 | 2006-12-04 |  | 0d |  | must start on 2006-12-04 |
| 3 | 1.2 | DWSM Engineering D2 | milestone | 0d | 2006-12-14 | 2006-12-14 |  | 0d |  | must start on 2006-12-14 |
| 4 | 1.3 | DWSM Engineering D3 | milestone | 0d | 2007-01-04 | 2007-01-04 |  | 0d |  | must start on 2007-01-04 |
| 5 | 1.4 | DWSM Engineering | milestone | 0d | 2007-02-05 | 2007-02-05 |  | 0d |  | must start on 2007-02-05 |
| 6 | 1.5 | 1k D-ESP Profiling |  | 1d | 2007-02-12 | 2007-02-12 |  | 0d |  | must start on 2007-02-12 |
| 7 | 1.6 | 1k D-ESP Profiling |  | 3d | 2007-03-05 | 2007-03-07 |  | 0d |  | must start on 2007-03-05 |
| 8 | 1.7 | GG Surface IN | milestone | 0d | 2007-04-16 | 2007-04-16 |  | 0d |  | must start on 2007-04-16 |
| 9 | 1.8 | GG Surface OUT | milestone | 0d | 2007-05-07 | 2007-05-07 |  | 0d |  | must start on 2007-05-07 |
| 10 | 1.9 | GG Surface IN | milestone | 0d | 2007-05-17 | 2007-05-17 |  | 0d |  | must start on 2007-05-17 |
| 11 | 1.10 | GG Surface OUT | milestone | 0d | 2007-06-12 | 2007-06-12 |  | 0d |  | must start on 2007-06-12 |
| 12 | 1.11 | ESP Network GG, TT1 IN | milestone | 0d | 2007-08-30 | 2007-08-30 |  | 0d |  | must start on 2007-08-30 |
| 13 | 1.12 | ESP Network GG, TT1 OUT | milestone | 0d | 2007-09-27 | 2007-09-27 | 130 | 0d |  | must start on 2007-09-27 |
| 15 | 2 | **GG CORE** |  | 75d | 2006-11-27 | 2007-03-09 |  | 15d |  |  |
| 16 | 2.1 | Predator Close out |  | 25d | 2006-11-27 | 2006-12-29 |  | 220d |  |  |
| 17 | 2.2 | Multi Threading |  | 15d | 2006-12-01 | 2006-12-21 |  | 11d |  | start no earlier than 2006-12-01 |
| 18 | 2.3 | Chemistry Coldroom test |  | 2d | 2006-12-06 | 2006-12-07 |  | 236d |  | start no earlier than 2006-12-06 |
| 19 | 2.4 | Hand over to Engineering | milestone | 0d | 2007-01-08 | 2007-01-08 | 17 | 0d |  | must start on 2007-01-08 |
| 20 | 2.5 | Can, Move to Cold Room |  | 1d | 2007-01-23 | 2007-01-23 | 19 | 2d | 0d | start no earlier than 2007-01-23 |
| 21 | 2.6 | Cold Room Test |  | 2d | 2007-01-24 | 2007-01-25 | 20 | 2d | 0d |  |
| 22 | 2.7 | Prepare GG for Integration |  | 5d | 2007-01-26 | 2007-02-01 | 21 | 2d | 0d |  |
| 23 | 2.8 | GG ready for Integration | milestone | 0d | 2007-02-01 | 2007-02-01 | 22 | 2d |  |  |
| 24 | 2.9 | GG back from D-ESP | milestone | 0d | 2007-03-09 | 2007-03-09 | 108 | 158d | 0d |  |
| 29 | 3 | **SURF-ESP** |  | 40d? | 2007-03-12 | 2007-05-07 |  | 235d |  |  |
| 30 | 3.1 | Asseble GG to surface Lid 1 |  | 5d | 2007-03-12 | 2007-03-16 | 24 | 158d | 0d |  |
| 31 | 3.2 | Load puck, reagnets, test run GG |  | 5d | 2007-03-19 | 2007-03-23 | 30 | 158d | 0d |  |
| 32 | 3.3 | Can for Deployment |  | 1d? | 2007-03-26 | 2007-03-26 | 31 | 158d | 0d |  |
| 33 | 3.4 | MOB |  | 1d? | 2007-03-27 | 2007-03-27 | 32 | 158d |  |  |
| 34 | 3.5 | Deployed |  | 10d | 2007-04-23 | 2007-05-07 | 8SS, 9FF | 130d |  |  |

| ID | WBS | Task | Type | Duration | Start | Finish | Predecessors | Total slack | Free slack | Constraint | Resources | Work |
| --- | --- | --- | --- | --- | --- | --- | --- | --- | --- | --- | --- | --- |
| 36 | 4 | **Micro-FluidicBlock** |  | 246d? | 2006-10-02 | 2007-09-10 |  | 144d |  |  |  | 3276h |
| 37 | 4.1 | PDR |  | 1d? | 2006-11-27 | 2006-11-27 |  | 349d |  |  |  |  |
| 38 | 4.2 | Detailed Design |  | 1d? | 2006-11-27 | 2006-11-27 |  | 349d |  |  |  |  |
| 39 | 4.3 | CDR |  | 1d? | 2006-11-27 | 2006-11-27 |  | 349d |  |  |  |  |
| 40 | 4.4 | Drawing Release |  | 1d? | 2006-11-27 | 2006-11-27 |  | 349d |  |  |  |  |
| 41 | 4.5 | Shop Fabriaction |  | 1d? | 2006-11-27 | 2006-11-27 |  | 349d |  |  |  |  |
| 42 | 4.6 | Board Fab |  | 1d? | 2006-11-27 | 2006-11-27 |  | 349d |  |  |  |  |
| 43 | 4.7 | Assembly |  | 1d? | 2006-11-27 | 2006-11-27 |  | 349d |  |  |  |  |
| 44 | 4.8 | **Benchtop Fluid Concept** |  | 65d | 2006-10-02 | 2006-12-29 |  | 144d |  |  |  | 700h |
| 45 | 4.8.1 | Ready electronics |  | 20d | 2006-10-02 | 2006-10-27 |  | 144d | 0d | start no earlier than 2006-10-02 | EE | 160h |
| 46 | 4.8.2 | Assemble temporary setup |  | 15d | 2006-10-30 | 2006-11-17 | 45 | 355d |  |  | ME | 120h |
| 47 | 4.8.3 | Assemble temporary setup |  | 10d | 2006-10-30 | 2006-11-10 | 45 | 144d | 0d |  | EE | 80h |
| 48 | 4.8.4 | Develop control s/w |  | 10d | 2006-11-13 | 2006-11-24 | 47 | 144d | 0d |  | SE | 80h |
| 49 | 4.8.5 | Test slug and valve control |  | 15d | 2006-11-27 | 2006-12-15 | 48 | 144d | 0d |  | SE; EE [50%] | 180h |
| 50 | 4.8.6 | Concept design document |  | 3d | 2006-12-18 | 2006-12-20 | 49 | 144d | 0d |  | ME | 24h |
| 51 | 4.8.7 | PDR Preparation |  | 7d | 2006-12-21 | 2006-12-29 | 50 | 144d | 0d |  | ME | 56h |
| 52 | 4.8.8 | PDR | milestone | 0d | 2006-12-29 | 2006-12-29 | 51 | 144d | 0d |  | Team |  |
| 53 | 4.9 | **Surface/benchtop design** |  | 48d? | 2007-01-01 | 2007-03-07 |  | 144d |  |  |  | 384h |
| 54 | 4.9.1 | Mechanical design |  | 14d | 2007-01-01 | 2007-01-18 | 52 | 144d | 0d |  | ME | 112h |
| 55 | 4.9.2 | Electrical Design |  | 14d | 2007-01-19 | 2007-02-07 | 54 | 144d | 0d |  | EE | 112h |
| 56 | 4.9.3 | Software Design |  | 14d | 2007-02-08 | 2007-02-27 | 55 | 144d | 0d |  | SE | 112h |
| 57 | 4.9.4 | Complete design doc |  | 5d | 2007-02-28 | 2007-03-06 | 56 | 144d | 0d |  | Team | 40h |
| 58 | 4.9.5 | CDR Preparation |  | 1d? | 2007-03-07 | 2007-03-07 | 57 | 144d | 0d |  | Team | 8h |
| 59 | 4.9.6 | CDR | milestone | 0d | 2007-03-07 | 2007-03-07 | 58 | 144d | 0d |  | Team |  |

| ID | WBS | Task | Duration | Start | Finish | Predecessors | Total slack | Free slack | Resources | Work |
| --- | --- | --- | --- | --- | --- | --- | --- | --- | --- | --- |
| 60 | 4.10 | **Surface/benchtop Fabrication** | 133d | 2007-03-08 | 2007-09-10 |  | 144d |  |  | 1064h |
| 61 | 4.10.1 | Procure fluidic parts | 21d | 2007-03-08 | 2007-04-05 | 59 | 144d | 0d | Kevin | 168h |
| 62 | 4.10.2 | fabrication of assembly | 21d | 2007-04-06 | 2007-05-04 | 61 | 144d | 0d | ME_Tech | 168h |
| 63 | 4.10.3 | Electrical assembly | 21d | 2007-05-07 | 2007-06-04 | 62 | 144d | 0d | EE_Tech | 168h |
| 64 | 4.10.4 | S/W development | 30d | 2007-06-05 | 2007-07-16 | 63 | 144d | 0d | SE | 240h |
| 65 | 4.10.5 | S/W Testing | 30d | 2007-07-17 | 2007-08-27 | 64 | 144d | 0d | SE | 240h |
| 66 | 4.10.6 | Calibration & Testing | 10d | 2007-08-28 | 2007-09-10 | 65 | 144d |  | Team | 80h |
| 67 | 4.11 | **Assay Development** | 10d? | 2006-11-27 | 2006-12-08 |  | 340d |  |  | 80h |
| 68 | 4.11.1 | SH Assay Development & Testing | 1d? | 2006-11-27 | 2006-11-27 |  | 340d | 0d | Science | 8h |
| 69 | 4.11.2 | PCR Assay Development & Testing | 1d? | 2006-11-28 | 2006-11-28 | 68 | 340d | 0d | Science | 8h |
| 70 | 4.11.3 | Probe validation and calibration | 1d? | 2006-11-29 | 2006-11-29 | 69 | 340d | 0d | Science | 8h |
| 71 | 4.11.4 | Identify possible positive control | 1d? | 2006-11-30 | 2006-11-30 | 70 | 340d | 0d | Science | 8h |
| 72 | 4.11.5 | Reagent stability test | 1d? | 2006-12-01 | 2006-12-01 | 71 | 340d | 0d | Science | 8h |
| 73 | 4.11.6 | Bench comparison w/ realistic sample volume | 1d? | 2006-12-04 | 2006-12-04 | 72 | 340d | 0d | Science | 8h |
| 74 | 4.11.7 | Run hybrid on bench, test with cold | 1d? | 2006-12-05 | 2006-12-05 | 73 | 340d | 0d | Science | 8h |
| 75 | 4.11.8 | **Science Test** | 3d? | 2006-12-06 | 2006-12-08 |  | 340d |  |  | 24h |
| 76 | 4.11.8.1 | ESP lab test (existing unit) | 1d? | 2006-12-06 | 2006-12-06 | 74 | 340d | 0d | Science | 8h |
| 77 | 4.11.8.2 | ESP Lab test (ASTEP dedicated unit) | 1d? | 2006-12-07 | 2006-12-07 | 76 | 340d | 0d | Science | 8h |
| 78 | 4.11.8.3 | Presentation and publications | 1d? | 2006-12-08 | 2006-12-08 | 77 | 340d |  | Science | 8h |
| 79 | 4.12 | Presentation and publications | 1d? | 2006-11-27 | 2006-11-27 |  | 349d |  | Science | 8h |
| 80 | 4.13 | **Ship based unit** | 95d | 2006-11-27 | 2007-04-06 |  | 255d |  |  | 1040h |
| 81 | 4.13.1 | Procurement | 30d | 2006-11-27 | 2007-01-05 |  | 255d | 0d | Kevin | 240h |
| 82 | 4.13.2 | Mechanical fab. | 10d | 2007-01-08 | 2007-01-19 | 81 | 310d |  | ME_Tech | 80h |
| 83 | 4.13.3 | Electrical Fab. | 10d | 2007-01-08 | 2007-01-19 | 81 | 310d |  | EE_Tech | 80h |
| 84 | 4.13.4 | S/W refinement | 20d | 2007-01-08 | 2007-02-02 | 81 | 255d | 0d | SE | 160h |
| 85 | 4.13.5 | GUI S/W integration | 15d | 2007-02-05 | 2007-02-23 | 84 | 285d |  | SE | 120h |
| 86 | 4.13.6 | Testing | 30d | 2007-02-05 | 2007-03-16 | 84 | 255d | 0d | SE | 240h |
| 87 | 4.13.7 | Protocol Development | 15d | 2007-03-19 | 2007-04-06 | 86 | 255d |  | SE | 120h |

| ID | WBS | Task | Type | Duration | Start | Finish | Predecessors | Total slack | Free slack | Constraint |
| --- | --- | --- | --- | --- | --- | --- | --- | --- | --- | --- |
| 89 | 5 | **LLNL PCR Module** |  | 298d? | 2007-02-07 | 2008-03-28 |  | 0d |  |  |
| 90 | 5.1 | CDR |  | 1d? | 2007-02-07 | 2007-02-07 |  | 192d | 0d | start no earlier than 2007-02-07 |
| 91 | 5.2 | Prototype Deomonstration |  | 5d | 2007-02-08 | 2007-02-14 | 90 | 192d | 0d |  |
| 92 | 5.3 | Deliver Electronics Prorotype |  | 20d | 2007-02-15 | 2007-03-14 | 91 | 192d | 0d | finish no earlier than 2007-03-12 |
| 93 | 5.4 | Deliver 4 PCR Module Prototypes |  | 80d | 2007-03-15 | 2007-07-04 | 92 | 192d |  |  |
| 94 | 5.5 | Support |  | 200d | 2007-06-25 | 2008-03-28 |  | 0d |  | finish no earlier than 2008-03-28 |
| 100 | 6 | **D-ESP** |  | 35d | 2007-01-22 | 2007-03-09 |  | 1d |  |  |
| 101 | 6.1 | Pre-Integration tasks (two gateway, etc) |  | 10d | 2007-01-22 | 2007-02-02 |  | 1d |  | start no earlier than 2007-01-22 |
| 102 | 6.2 | Integrate GG with DWSM |  | 9d | 2007-02-06 | 2007-02-16 | 143, 23, 101 | 0d |  | start no earlier than 2007-01-01 |
| 103 | 6.3 | Can for PDV |  | 5d | 2007-02-19 | 2007-02-23 | 102 | 0d |  |  |
| 104 | 6.4 | PDV |  | 2d | 2007-02-26 | 2007-02-27 | 103 | 0d |  |  |
| 105 | 6.5 | Can for Dep |  | 2d | 2007-02-28 | 2007-03-01 | 104 | 0d |  |  |
| 106 | 6.6 | MOB |  | 1d | 2007-03-02 | 2007-03-02 | 105 | 0d |  | start no earlier than 2007-02-09 |
| 107 | 6.7 | 1k D-ESP Profiling |  | 3d | 2007-03-05 | 2007-03-07 | 6SS, 106 | 0d |  | must start on 2007-03-05 |
| 108 | 6.8 | De-MOB |  | 2d | 2007-03-08 | 2007-03-09 | 107 | 263d | 0d |  |
| 111 | 7 | **ASTEP CORE** |  | 240d | 2006-12-04 | 2007-11-02 |  | 105d |  |  |
| 112 | 7.1 | A1 Build Up |  | 60d | 2006-12-04 | 2007-02-23 |  | 105d | 0d | start no earlier than 2006-12-04 |
| 113 | 7.2 | A1 BUILT | milestone | 0d | 2007-02-23 | 2007-02-23 | 112 | 105d | 0d |  |
| 114 | 7.3 | A1 Engr Test-Out |  | 60d | 2007-02-26 | 2007-05-18 | 113 | 105d | 0d |  |
| 115 | 7.4 | Handover to Science | milestone | 0d | 2007-05-18 | 2007-05-18 | 114 | 105d | 0d |  |
| 116 | 7.5 | A1 Validation |  | 20d | 2007-05-21 | 2007-06-15 | 115 | 105d | 0d |  |
| 117 | 7.6 | Handback to Engineering | milestone | 0d | 2007-06-15 | 2007-06-15 | 116 | 105d | 0d |  |
| 118 | 7.7 | PCR Integration |  | 100d | 2007-06-18 | 2007-11-02 | 117 | 105d |  |  |
| 120 | 8 | **TT CORES** |  | 168d | 2007-02-05 | 2007-09-26 |  | 132d |  |  |
| 121 | 8.1 | **+3 Build Up** |  | 90d | 2007-02-05 | 2007-06-08 |  | 170d | 4d |  |
| 122 | 8.1.1 | Build Sub-assemblies |  | 30d | 2007-02-05 | 2007-03-16 |  | 170d | 0d | start no earlier than 2007-02-05 |
| 123 | 8.1.2 | Frame Assembly |  | 30d | 2007-03-19 | 2007-04-27 | 122 | 170d | 0d | start no earlier than 2007-01-01 |
| 124 | 8.1.3 | Electrical and Plumbing |  | 30d | 2007-04-30 | 2007-06-08 | 123 | 170d |  | start no earlier than 2007-01-01 |
| 125 | 8.2 | +3 Built | milestone | 0d | 2007-06-15 | 2007-06-15 | 121 | 166d | 0d | start no earlier than 2007-06-15 |
| 126 | 8.3 | +3 Engr Test-Out |  | 20d | 2007-06-15 | 2007-07-12 | 125 | 166d | 0d |  |
| 127 | 8.4 | Handover to science | milestone | 0d | 2007-07-12 | 2007-07-12 | 126 | 166d | 0d |  |
| 128 | 8.5 | +3 Validation |  | 20d | 2007-07-13 | 2007-08-09 | 127 | 166d |  |  |
| 130 | 8.6 | TT1 Net Dep |  | 20d | 2007-08-30 | 2007-09-26 | 12 | 0d |  |  |

| ID | WBS | Task | Type | Duration | Start | Finish | Predecessors | Total slack | Free slack | Constraint |
| --- | --- | --- | --- | --- | --- | --- | --- | --- | --- | --- |
| 131 | 9 | **1K DWSM** |  | 46d | 2006-12-04 | 2007-02-05 |  | 0d |  |  |
| 132 | 9.1 | Seal Mods, Thru can plumbing |  | 6d | 2006-12-04 | 2006-12-11 | 2 | 3d | 0d |  |
| 133 | 9.2 | Can DWSM, Test out |  | 1d | 2006-12-12 | 2006-12-12 | 132 | 3d | 0d |  |
| 134 | 9.3 | MOB |  | 1d | 2006-12-13 | 2006-12-13 | 133 | 3d | 0d |  |
| 135 | 9.4 | VENTANA DEPLOY |  | 1d | 2006-12-14 | 2006-12-14 | 134 | 3d | 0d |  |
| 136 | 9.5 | Modifications |  | 10d | 2006-12-15 | 2006-12-28 | 135 | 3d |  |  |
| 137 | 9.6 | MOB |  | 1d | 2007-01-03 | 2007-01-03 | 136 | 0d |  | start no earlier than 2007-01-03 |
| 138 | 9.7 | VENTANA DEPLOY |  | 1d | 2007-01-04 | 2007-01-04 | 137 | 0d |  |  |
| 139 | 9.8 | Seal Validation, Valve change, cold room |  | 19d | 2007-01-05 | 2007-01-31 | 138 | 0d |  |  |
| 140 | 9.9 | Can DWSM, Test out |  | 1d | 2007-02-01 | 2007-02-01 | 139 | 0d |  | start no earlier than 2007-02-01 |
| 141 | 9.10 | MOB |  | 1d | 2007-02-02 | 2007-02-02 | 140 | 0d |  | start no earlier than 2007-02-02 |
| 142 | 9.11 | VENTANA DEPLOY |  | 1d | 2007-02-05 | 2007-02-05 | 141 | 0d |  |  |
| 143 | 9.12 | Turn over for D-ESP Integration | milestone | 0d | 2007-02-05 | 2007-02-05 | 142 | 0d |  |  |
| 145 | 10 | **Surface Mooring A** |  | 59d? | 2006-11-27 | 2007-02-15 |  | 291d |  |  |
| 146 | 10.1 | Feed-thru's arrive | milestone | 0d | 2007-02-05 | 2007-02-05 |  | 291d | 0d | start no earlier than 2007-02-05 |
| 147 | 10.2 | Populate 2nd housing lid |  | 5d | 2007-02-05 | 2007-02-09 | 146 | 291d | 0d |  |
| 148 | 10.3 | Build up test anchor/float/can |  | 1d | 2007-02-12 | 2007-02-12 | 147 | 291d | 0d |  |
| 149 | 10.4 | Hydro 2nd housing |  | 3d | 2007-02-13 | 2007-02-15 | 148 | 291d |  |  |
| 150 | 10.5 | Build up Surface mooring A |  | 1d? | 2006-11-27 | 2006-11-27 |  | 349d |  |  |
| 153 | 10.6 | Battery Charging |  | 1d? | 2006-11-27 | 2006-11-27 |  | 349d |  |  |
