# ESP_NOAA_v0

Schedule from MS Project, 2006-08-02 to 2009-08-31.
MBARI

## Calendars

- Standard: Mon-Fri 08:00-12:00, 13:00-17:00; Sat-Sun off.

## Resources

| Resource |
| --- |
| Software |
| SE |
| ME |
| ME_Tech |
| Team |
| EE |
| EE_Tech |
| Scott |
| Gene |
| Mark Brown |
| Brent |
| Roman |
| Kevin |
| Kevni |
| Conway |
| Mechatronic |
| Science |

## Schedule

| ID | WBS | Task | Duration | Start | Finish | Predecessors | Total slack | Free slack | Constraint |
| --- | --- | --- | --- | --- | --- | --- | --- | --- | --- |
| 2 | 1 | Y2 Deployments | 1d? | 2006-08-02 | 2006-08-02 |  | 760d |  |  |
| 3 | 2 | **Florida** | 118d | 2008-08-18 | 2009-01-28 |  | 153d |  |  |
| 4 | 2.1 | Deployment Prep (at MBARI) | 20d | 2008-08-18 | 2008-09-12 |  | 153d | 0d | start no earlier than 2008-08-18 |
| 5 | 2.2 | In transit | 5d | 2008-09-15 | 2008-09-19 | 4 | 153d | 0d |  |
| 6 | 2.3 | Checkout | 5d | 2008-09-22 | 2008-09-26 | 5 | 153d | 0d |  |
| 7 | 2.4 | Assemble | 5d | 2008-09-29 | 2008-10-03 | 6 | 153d | 0d |  |
| 8 | 2.5 | Window | 40d | 2008-10-06 | 2008-11-28 | 7 | 153d | 0d | start no earlier than 2008-10-01 |
| 9 | 2.6 | Deploy | 2d | 2008-12-01 | 2008-12-02 | 8 | 153d | 0d |  |
| 10 | 2.7 | In water | 22d | 2008-12-03 | 2009-01-01 | 9 | 153d | 0d |  |
| 11 | 2.8 | Recover | 2d | 2009-01-02 | 2009-01-05 | 10 | 153d | 0d |  |
| 12 | 2.9 | Closeout | 10d | 2009-01-06 | 2009-01-19 | 11 | 153d | 0d | start no earlier than 2006-10-30 |
| 13 | 2.10 | Package | 2d | 2009-01-20 | 2009-01-21 | 12 | 153d | 0d | start no earlier than 2006-10-30 |
| 14 | 2.11 | Ship Home | 5d | 2009-01-22 | 2009-01-28 | 13 | 153d |  | start no earlier than 2006-10-30 |
| 16 | 3 | **Massachusetts** | 121d? | 2009-03-16 | 2009-08-31 |  | 0d |  |  |
| 17 | 3.1 | Deployment Prep (at MBARI) | 20d | 2009-03-16 | 2009-04-10 |  | 0d |  | start no earlier than 2009-03-16 |
| 18 | 3.2 | In transit | 5d | 2009-04-13 | 2009-04-17 | 17 | 0d |  | start no earlier than 2007-10-29 |
| 19 | 3.3 | Checkout | 5d | 2009-04-20 | 2009-04-24 | 18 | 0d |  | start no earlier than 2007-11-05 |
| 20 | 3.4 | Assemble | 5d | 2009-04-27 | 2009-05-01 | 19 | 0d |  | start no earlier than 2007-11-12 |
| 21 | 3.5 | Deploy | 2d | 2009-05-04 | 2009-05-05 | 20 | 0d |  | start no earlier than 2007-11-19 |
| 22 | 3.6 | Window | 43d? | 2009-05-06 | 2009-07-03 | 21 | 0d |  | start no earlier than 2009-05-01 |
| 23 | 3.7 | In water | 22d | 2009-07-06 | 2009-08-04 | 22 | 0d |  | start no earlier than 2007-11-21 |
| 24 | 3.8 | Recover | 2d | 2009-08-05 | 2009-08-06 | 23 | 0d |  | start no earlier than 2007-12-21 |
| 25 | 3.9 | Closeout | 10d | 2009-08-07 | 2009-08-20 | 24 | 0d |  | start no earlier than 2007-12-25 |
| 26 | 3.10 | Package | 2d | 2009-08-21 | 2009-08-24 | 25 | 0d |  | start no earlier than 2008-01-08 |
| 27 | 3.11 | Ship Home | 5d | 2009-08-25 | 2009-08-31 | 26 | 0d |  | start no earlier than 2008-01-10 |

| ID | WBS | Task | Duration | Start | Finish | Predecessors | Total slack | Free slack | Constraint |
| --- | --- | --- | --- | --- | --- | --- | --- | --- | --- |
| 29 | 4 | **Pacific Northwest** | 121d? | 2009-03-16 | 2009-08-31 |  | 0d |  |  |
| 30 | 4.1 | Deployment Prep (at MBARI) | 20d | 2009-03-16 | 2009-04-10 |  | 0d |  | start no earlier than 2009-03-16 |
| 31 | 4.2 | In transit | 5d | 2009-04-13 | 2009-04-17 | 30 | 0d |  | start no earlier than 2007-10-29 |
| 32 | 4.3 | Checkout | 5d | 2009-04-20 | 2009-04-24 | 31 | 0d |  | start no earlier than 2007-11-05 |
| 33 | 4.4 | Assemble | 5d | 2009-04-27 | 2009-05-01 | 32 | 0d |  | start no earlier than 2007-11-12 |
| 34 | 4.5 | Deploy | 2d | 2009-05-04 | 2009-05-05 | 33 | 0d |  | start no earlier than 2007-11-19 |
| 35 | 4.6 | Window | 43d? | 2009-05-06 | 2009-07-03 | 34 | 0d |  | start no earlier than 2009-05-01 |
| 36 | 4.7 | In water | 22d | 2009-07-06 | 2009-08-04 | 35 | 0d |  | start no earlier than 2007-11-21 |
| 37 | 4.8 | Recover | 2d | 2009-08-05 | 2009-08-06 | 36 | 0d |  | start no earlier than 2007-12-21 |
| 38 | 4.9 | Closeout | 10d | 2009-08-07 | 2009-08-20 | 37 | 0d |  | start no earlier than 2007-12-25 |
| 39 | 4.10 | Package | 2d | 2009-08-21 | 2009-08-24 | 38 | 0d |  | start no earlier than 2008-01-08 |
| 40 | 4.11 | Ship Home | 5d | 2009-08-25 | 2009-08-31 | 39 | 0d |  | start no earlier than 2008-01-10 |
| 42 | 5 | **Monterey** | 111d? | 2009-03-16 | 2009-08-17 |  | 10d |  |  |
| 43 | 5.1 | Deployment Prep (at MBARI) | 20d | 2009-03-16 | 2009-04-10 |  | 17d | 0d | start no earlier than 2009-03-16 |
| 44 | 5.2 | Assemble | 5d | 2009-04-13 | 2009-04-17 | 43 | 17d | 0d | start no earlier than 2007-11-12 |
| 45 | 5.3 | Deploy | 2d | 2009-04-20 | 2009-04-21 | 44 | 17d | 7d | start no earlier than 2007-11-19 |
| 46 | 5.4 | Window | 43d? | 2009-05-01 | 2009-06-30 | 45 | 10d | 0d | start no earlier than 2009-05-01 |
| 47 | 5.5 | In water | 22d | 2009-07-01 | 2009-07-30 | 46 | 10d | 0d | start no earlier than 2007-11-21 |
| 48 | 5.6 | Recover | 2d | 2009-07-31 | 2009-08-03 | 47 | 10d | 0d | start no earlier than 2007-12-21 |
| 49 | 5.7 | Closeout | 10d | 2009-08-04 | 2009-08-17 | 48 | 10d |  | start no earlier than 2007-12-25 |
